# Technológiai3

Schedule from MS Project, 2007-10-01 to 2007-11-09.

## Calendars

- Szabványos: Mon-Fri 08:00-12:00, 13:00-17:00; Sat-Sun off.

## Schedule

| ID | Task | Type | Duration | Start | Finish | Predecessors | Total slack |
| --- | --- | --- | --- | --- | --- | --- | --- |
| 1 | Anyagok kiszállítása |  | 1d | 2007-10-01 | 2007-10-01 |  | 0d |
| 2 | Járda helyének előkészítése |  | 2d | 2007-10-02 | 2007-10-03 | 1 | 0d |
| 3 | Zsaluzás, ágyazatkészítés |  | 1d | 2007-10-04 | 2007-10-04 | 2 | 0d |
| 4 | Járdabetonozás |  | 2d | 2007-10-05 | 2007-10-08 | 3 | 0d |
| 5 | !Kizsaluzhatósági idő |  | 2ed | 2007-10-08 | 2007-10-10 | 4 | 1.88d |
| 6 | Kizsaluzás |  | 1d | 2007-10-11 | 2007-10-11 | 5 | 0d |
| 7 | Tereprendezés, zsaluanyagok, sitt elszállítása |  | 1d | 2007-10-12 | 2007-10-12 | 6 | 0d |
| 8 | !Kötési idő |  | 28ed | 2007-10-12 | 2007-11-09 | 7 | 0d |
| 9 | Terület átadása a megbízónak | milestone | 0d | 2007-11-09 | 2007-11-09 | 8 | 0d |
